# 01-CRONOGRAMA GUACAMAYAS V1

Schedule from MS Project, 2021-01-01 to 2021-06-17.

## Calendars

- Estándar: Mon-Fri 09:00-13:00, 15:00-19:00; Sat-Sun 09:00-13:00, 15:00-16:00.

## Schedule

| ID | WBS | Task | Type | Duration | Start | Finish | Predecessors | Total slack | Free slack |
| --- | --- | --- | --- | --- | --- | --- | --- | --- | --- |
| 1 | 1 | **Levantamiento topográfico con tecnología de LiDAR aéreo proyecto: Ajustes, actualización y complementación de la factibilidad y estudios y diseños del cable San Cristóbal, en Bogotá.** |  | 150d | 2021-01-01 | 2021-06-17 |  | 0d |  |
| 2 | 1.1 | **ALISTAMIENTO** |  | 13d | 2021-01-01 | 2021-01-15 |  | 0d |  |
| 3 | 1.1.1 | HITO-1 FIRMA ACTA DE INICIO | milestone | 0d | 2021-01-01 | 2021-01-01 |  | 0d |  |
| 4 | 1.1.2 | Planeamiento y diagnostico inicial del proyecto, verificación de alcance, determinación de polígonos Límite de proyecto, entrega del plan de trabajo y cronograma de actividades. |  | 3d | 2021-01-01 | 2021-01-04 | 3 | 0d |  |
| 5 | 1.1.3 | Solicitud de permisos e insumos básicos para el inicio de actividades |  | 10d | 2021-01-04 | 2021-01-15 | 4 | 137d |  |
| 6 | 1.1.4 | Determinación e identificación de la red autónoma de estaciones permanentes y/o puntos geodésicos del IGAC para el amarre y control de los puntos GCP´s proyectados (Marco de Referencia GNSS). |  | 1d | 2021-01-04 | 2021-01-05 | 4 | 0d |  |
| 7 | 1.1.5 | Diseño del Marco de Referencia (puntos GCP´s), incluye límite de proyecto fase de estudios y diseños y puntos de amarre y/o ubicación de estaciones permanentes del IGAC a utilizar. |  | 1d | 2021-01-05 | 2021-01-06 | 4, 6 | 0d |  |
| 8 | 1.1.6 | Diseño plan de vuelo único |  | 2d | 2021-01-06 | 2021-01-08 | 7 | 0d |  |
| 9 | 1.1.7 | Alistamiento y configuración de equipos |  | 2d | 2021-01-08 | 2021-01-11 | 8 | 0d |  |
| 10 | 1.1.8 | Inducción del personal de campo y oficina |  | 1d | 2021-01-11 | 2021-01-12 | 9 | 0d |  |
| 11 | 1.1.9 | HITO-2 MOVILIZACIÓN AL SITIO DE TRABAJO | milestone | 0d | 2021-01-12 | 2021-01-12 | 10 | 0d |  |
| 12 | 1.2 | **TOMA DE INFORMACIÓN EN CAMPO** |  | 77d | 2021-01-12 | 2021-04-08 |  | 0d |  |
| 13 | 1.2.1 | **Toma de datos en Tierra** |  | 77d | 2021-01-12 | 2021-04-08 |  | 0d |  |
| 14 | 1.2.1.1 | Reconocimiento directo de áreas o polígonos limite de proyecto. |  | 1d | 2021-01-12 | 2021-01-13 | 11 | 0d |  |
| 15 | 1.2.1.2 | Materialización e Iluminación del Marco de Referencia (puntos GCP´s proyectados). |  | 3d | 2021-01-13 | 2021-01-16 | 14 | 0d |  |
| 16 | 1.2.1.3 | Posicionamiento y/o Georreferenciación GNSS del Marco de Referencia (puntos GCP´s proyectados). |  | 6d | 2021-03-09 | 2021-03-16 | 33 | 0d |  |
| 17 | 1.2.1.4 | Nivelación geométrica del Marco de Referencia GNSS |  | 6d | 2021-03-16 | 2021-03-22 | 16 | 0d |  |
| 18 | 1.2.1.5 | Levantamientos puntuales en sitios de pilonas proyectadas (Laser Terrestre) |  | 15d | 2021-03-23 | 2021-04-08 | 17 | 63d |  |
| 19 | 1.2.2 | **Toma de datos en Aire** |  | 8d | 2021-01-16 | 2021-01-25 |  | 0d |  |
| 20 | 1.2.2.1 | Montaje y calibración del sistema LIDAR |  | 2d | 2021-01-16 | 2021-01-19 | 15 | 0d |  |
| 21 | 1.2.2.2 | Verificación de Iluminación de puntos de control GCP´s |  | 1d | 2021-01-19 | 2021-01-20 | 20 | 0d |  |
| 22 | 1.2.2.3 | Sobrevuelos y Captura de datos Lidar y Fotogramétricos |  | 5d | 2021-01-20 | 2021-01-25 | 21 | 0d |  |
| 23 | 1.2.3 | HITO-3 TERMINACION DE ACTIVIDADES DE CAMPO | milestone | 0d | 2021-01-25 | 2021-01-25 | 22 | 102d | 0d |
| 24 | 1.3 | **PRODUCCIÓN Y ENTREGABLES FASE DE FACTIBILIDAD 1:2000 (POL. 7Km X 200m)** |  | 38d | 2021-01-26 | 2021-03-09 |  | 0d |  |
| 25 | 1.3.1 | **POS PROCESO LIDAR Y FOTOGRAMÉTRICOS - FASE DE FACTIBILIDAD** |  | 10d | 2021-01-26 | 2021-02-05 |  | 0d |  |
| 26 | 1.3.1.1 | Pos Proceso grueso de datos LIDAR |  | 10d | 2021-01-26 | 2021-02-05 | 23 | 102d | 0d |
| 27 | 1.3.1.2 | Pos Proceso grueso de datos FOTOGRAMÉTRICOS |  | 10d | 2021-01-26 | 2021-02-05 | 22 | 0d |  |

| ID | WBS | Task | Type | Duration | Start | Finish | Predecessors | Total slack | Free slack |
| --- | --- | --- | --- | --- | --- | --- | --- | --- | --- |
| 28 | 1.3.2 | **CONSTRUCCIÓN DE PRODUCTOS Y ENTREGABLES - FASE DE FACTIBILIDAD** |  | 28d | 2021-02-05 | 2021-03-09 |  | 0d |  |
| 29 | 1.3.2.1 | Construcción de Modelo Digital de Superficie MDS grueso |  | 8d | 2021-02-05 | 2021-02-15 | 26 | 102d | 0d |
| 30 | 1.3.2.2 | Construcción de Modelo Digital de Terreno MDT grueso - paso de malla 1m |  | 8d | 2021-02-15 | 2021-02-23 | 29 | 102d |  |
| 31 | 1.3.2.3 | Construcción de orto-foto-mosaico grueso 15 cm/pixel |  | 8d | 2021-02-05 | 2021-02-15 | 27 | 0d |  |
| 32 | 1.3.2.4 | Construcción de Cartografía básica vectorial 2D |  | 20d | 2021-02-15 | 2021-03-09 | 31 | 0d |  |
| 33 | 1.3.2.5 | HITO-4 FIN FASE DE FACTIBILIDAD | milestone | 0d | 2021-03-09 | 2021-03-09 | 32 | 0d |  |
| 34 | 1.4 | **PRODUCCIÓN Y ENTREGABLES FASE DE ESTUDIOS Y DISEÑOS 1:500 (POL. 3Km X 100m)** |  | 78d | 2021-03-23 | 2021-06-17 |  | 0d |  |
| 35 | 1.4.1 | **MARCO DE REFERENCIA GNSS - FASE DE ESTUDIOS Y DISEÑOS** |  | 9d | 2021-03-23 | 2021-04-01 |  | 0d |  |
| 36 | 1.4.1.1 | Post-proceso Marco de Referencia GNSS (puntos GCP´s) |  | 4d | 2021-03-23 | 2021-03-26 | 17, 33 | 0d |  |
| 37 | 1.4.1.2 | Compendio de coordenadas y cotas - Marco de Referencia |  | 2d | 2021-03-27 | 2021-03-29 | 36 | 0d |  |
| 38 | 1.4.1.3 | Construcción de fichas de localización espacial de puntos GCP´s |  | 3d | 2021-03-29 | 2021-04-01 | 37 | 0d |  |
| 39 | 1.4.2 | **POS PROCESO LIDAR Y FOTOGRAMÉTRICOS - FASE DE ESTUDIOS Y DISEÑOS** |  | 25d | 2021-04-01 | 2021-04-29 |  | 0d |  |
| 40 | 1.4.2.1 | Pos Proceso fino de datos LIDAR |  | 25d | 2021-04-01 | 2021-04-29 | 38 | 9d | 0d |
| 41 | 1.4.2.2 | Pos Proceso fino de datos FOTOGRAMÉTRICOS |  | 25d | 2021-04-01 | 2021-04-29 | 38 | 0d |  |
| 42 | 1.4.3 | **CONSTRUCCIÓN DE PRODUCTOS Y ENTREGABLES - FASE DE ESTUDIOS Y DISEÑOS** |  | 44d | 2021-04-29 | 2021-06-17 |  | 0d |  |
| 43 | 1.4.3.1 | Construcción de Modelo Digital de Superficie MDS fino |  | 15d | 2021-04-29 | 2021-05-16 | 40 | 9d | 0d |
| 44 | 1.4.3.2 | Construcción de Modelo Digital de Terreno MDT fino - paso de malla 10cm |  | 15d | 2021-05-17 | 2021-06-02 | 43 | 9d | 0d |
| 45 | 1.4.3.3 | Construcción de Curvados |  | 5d | 2021-06-02 | 2021-06-08 | 44 | 9d |  |
| 46 | 1.4.3.4 | Construcción de orto-foto-mosaico fino 5 cm/pixel |  | 15d | 2021-04-29 | 2021-05-16 | 41 | 0d |  |
| 47 | 1.4.3.5 | Construcción de Cartografía básica vectorial 3D |  | 29d | 2021-05-17 | 2021-06-17 | 46 | 0d |  |
| 48 | 1.4.3.6 | Construcción de Informe final y anexos |  | 8d | 2021-06-09 | 2021-06-17 | 47FF | 0d |  |
| 49 | 1.4.3.7 | HITO-5 FIN FASE DE ESTUDIOS Y DISEÑOS - FIN DEL LEVANTAMIENTO TOPOGRAFICO | milestone | 0d | 2021-06-17 | 2021-06-17 | 48 | 0d |  |
